# SOW 3.1 Project Plan v1

Schedule from MS Project, 2005-01-03 to 2006-04-10, A marks actual dates.
NeuStar, Inc.

## Calendars

- Standard: Mon-Fri 08:00-12:00, 13:00-17:00; Sat-Sun off. Exceptions (off unless hours are given): 2006-02-12 08:00-12:00, 13:00-17:00, 2006-02-19 08:00-12:00, 13:00-17:00, 2006-02-26 08:00-12:00, 13:00-17:00, 2006-03-19 08:00-12:00, 13:00-17:00, 2006-03-26 08:00-12:00, 13:00-17:00, 2006-04-02 08:00-12:00, 13:00-17:00, 2006-04-09 08:00-12:00, 13:00-17:00.

## Resources

| Resource |
| --- |
| NeuStar |
| ESI |
| NeuStar |
| Industry |
| In |
| TSE |
| LNPA |
| LNPA Co Chair |
| All |
| NE Region |
| Super Region |
| NeuStar |
| ACGS |
| Mantiss |
| TTI |
| MCIW |
| ATT |
| Inlogic |
| Lucent |
| Telcordia |
| Tekelec |
| Connection |
| NE |
| NE Technologies |
| LNPA WG |
| Vendors |
| SPs |
| WCOM |
| Industry |
| Region 2 |
| NAPM LLC |
| Region 3 |
| Region 4 |
| Region 5 |
| NPAM LLC |
| Region 6 |
| Region 7 |
| NeuStar Service Delivery |
| NeuStar |
| Raviant |
| NeuStar |
| Illuminet |
| Ky |
| NeuStar (Ky) |
| NeuStat |
| NeuStar Engineering |
| All SPs |
| SPs and NeuStar |
| NeuStar/Industry |
| NeuStar & vendors |
| NeuStar/Vendor |
| NeuStar/All SPs |

## Schedule

| ID | WBS | Task | Type | Duration | Start | Finish | Predecessors | Complete | Remaining | Total slack | Constraint | Resources | Work | Actual work |
| --- | --- | --- | --- | --- | --- | --- | --- | --- | --- | --- | --- | --- | --- | --- |
| 1 | 1 | **NPAC Release 3.3 Implementation** |  | 337d | 2005-01-03 A | 2006-04-10 |  | 70% | 102.7d | 0d |  |  | 5200h | 3768h |
| 2 | 1.1 | NeuStar Acceptance of changes |  | 15d | 2005-08-22 A | 2005-09-09 A | 61 | 100% |  |  | finish no earlier than 2002-10-11 | NeuStar | 120h | 120h |
| 3 | 1.2 | **Phase 1.0** |  | 261d | 2005-01-03 A | 2006-01-03 |  | 83% | 45.22d | 76d |  |  | 3480h | 3024h |
| 4 | 1.2.1 | Effective Start Date | milestone | 0d | 2005-01-03 A | 2005-01-03 A |  | 100% |  |  | start no earlier than 2005-01-03 |  |  |  |
| 5 | 1.2.2 | SOW Effective Date | milestone | 0d | 2005-01-21 A | 2005-01-21 A |  | 100% |  |  | start no earlier than 2005-01-21 | Industry; NeuStar |  |  |
| 7 | 1.2.3 | **Phase 1.1 Develop SOW Project Plan** |  | 22d | 2005-02-10 A | 2005-03-11 A |  | 100% |  |  |  |  | 304h | 304h |
| 8 | 1.2.3.1 | Draft Project Plan delivered to LLC | milestone | 0d | 2005-02-10 A | 2005-02-10 A | 5 | 100% |  |  | start no earlier than 2005-02-10 | NeuStar |  |  |
| 9 | 1.2.3.2 | Project Plan - Review |  | 6d | 2005-02-10 A | 2005-02-17 A | 8 | 100% |  |  | start no earlier than 2002-08-01 | LNPA | 48h | 48h |
| 10 | 1.2.3.3 | Project Plan Final Delivery |  | 16d | 2005-02-18 A | 2005-03-11 A | 9 | 100% |  |  | finish no earlier than 2002-09-18 | LNPA; NeuStar | 256h | 256h |
| 12 | 1.2.4 | **Phase 1.2 Design and Develop Enhancement** |  | 185d | 2005-03-11 A | 2005-11-25 |  | 78% | 41.11d | 103d |  |  | 432h | 336h |
| 13 | 1.2.4.1 | **GDMO/ASN.1 Spec Completion** |  | 25d | 2005-03-11 A | 2005-04-15 A |  | 100% |  |  |  |  | 80h | 80h |
| 14 | 1.2.4.1.1 | GDMO/ASN.1 Draft #1 published on web site | milestone | 0d | 2005-03-11 A | 2005-03-11 A |  | 100% |  |  | start no earlier than 2005-03-11 | NeuStar |  |  |
| 15 | 1.2.4.1.2 | GDMO/ASN.1 Draft #1 review period by Industry |  | 6d | 2005-03-11 A | 2005-03-18 A | 14 | 100% |  |  | start no earlier than 2002-07-25 | Industry | 48h | 48h |
| 16 | 1.2.4.1.3 | GDMO/ASN.1 Draft #2 published on web site | milestone | 0d | 2005-04-08 A | 2005-04-08 A |  | 100% |  |  | start no earlier than 2005-04-08 | NeuStar |  |  |
| 17 | 1.2.4.1.4 | GDMO/ASN.1 Draft #2 review period by Industry |  | 4d | 2005-04-08 A | 2005-04-13 A | 16 | 100% |  |  | start no earlier than 2002-08-23 | Industry | 32h | 32h |
| 18 | 1.2.4.1.5 | GDMO/ASN.1 Final Version distributed | milestone | 0d | 2005-04-15 A | 2005-04-15 A |  | 100% |  |  | start no earlier than 2005-04-15 | NeuStar |  |  |
| 19 | 1.2.4.2 | **FRS Integrated Document Completion** |  | 39d | 2005-03-28 A | 2005-05-20 A |  | 100% |  |  |  |  | 88h | 88h |
| 20 | 1.2.4.2.1 | FRS Draft #1 Integrated Document distributed to Industry | milestone | 0d | 2005-03-28 A | 2005-03-28 A |  | 100% |  |  | start no earlier than 2005-03-28 | NeuStar |  |  |
| 21 | 1.2.4.2.2 | FRS Draft #1 review period by Industry |  | 5d | 2005-03-28 A | 2005-04-01 A | 20 | 100% |  |  | start no earlier than 2002-08-12 | Industry | 40h | 40h |
| 22 | 1.2.4.2.3 | FRS Draft #2 Integrated Document distributed to Industry | milestone | 0d | 2005-04-22 A | 2005-04-22 A |  | 100% |  |  | start no earlier than 2005-04-22 | NeuStar |  |  |
| 23 | 1.2.4.2.4 | FRS Draft #2 review period by Industry |  | 6d | 2005-04-22 A | 2005-04-29 A | 22 | 100% |  |  | start no earlier than 2002-09-04 | Industry | 48h | 48h |
| 24 | 1.2.4.2.5 | FRS Proposed Final Integrated Document | milestone | 0d | 2005-05-06 A | 2005-05-06 A |  | 100% |  |  | start no earlier than 2005-05-06 | NeuStar |  |  |
| 25 | 1.2.4.2.6 | FRS Final Integrated Document (3.3.0a) | milestone | 0d | 2005-05-20 A | 2005-05-20 A |  | 100% |  |  | start no earlier than 2005-05-20 | NeuStar |  |  |
| 26 | 1.2.4.3 | **IIS Integrated Document Completion** |  | 39d | 2005-04-25 A | 2005-06-17 A |  | 100% |  |  |  |  | 168h | 168h |
| 27 | 1.2.4.3.1 | IIS Draft #1 Integrated Document distributed to Industry | milestone | 0d | 2005-04-25 A | 2005-04-25 A |  | 100% |  |  | start no earlier than 2005-04-25 | NeuStar |  |  |
| 28 | 1.2.4.3.2 | IIS Draft #1 review period by Industry |  | 10d | 2005-04-25 A | 2005-05-06 A | 27 | 100% |  |  | start no earlier than 2002-09-09 | Industry | 80h | 80h |
| 29 | 1.2.4.3.3 | IIS Draft #2 Integrated Document distributed to Industry | milestone | 0d | 2005-05-27 A | 2005-05-27 A |  | 100% |  |  | start no earlier than 2005-05-27 | NeuStar |  |  |
| 30 | 1.2.4.3.4 | IIS Draft #2 review period by Industry |  | 11d | 2005-05-27 A | 2005-06-10 A | 29 | 100% |  |  | finish no earlier than 2002-10-16 | Industry | 88h | 88h |
| 31 | 1.2.4.3.5 | IIS Final Integrated Document (3.3.0a) | milestone | 0d | 2005-06-17 A | 2005-06-17 A |  | 100% |  |  | start no earlier than 2005-06-17 | NeuStar |  |  |

| ID | WBS | Task | Type | Duration | Start | Finish | Predecessors | Complete | Remaining | Total slack | Free slack | Constraint | Resources | Work | Actual work |
| --- | --- | --- | --- | --- | --- | --- | --- | --- | --- | --- | --- | --- | --- | --- | --- |
| 32 | 1.2.4.4 | **M&P Development Completion** |  | 30d | 2005-10-14 A | 2005-11-25 |  |  | 30d | 103d |  |  |  | 96h |  |
| 33 | 1.2.4.4.1 | M&Ps Draft #1 distributed to Industry | milestone | 0d | 2005-10-14 A | 2005-10-14 A |  | 100% |  |  |  | start no earlier than 2005-10-14 | NeuStar |  |  |
| 34 | 1.2.4.4.2 | M&Ps Draft #1 review period by Industry |  | 6d | 2005-10-14 | 2005-10-21 | 33 |  |  | 127d |  | start no earlier than 2003-02-24 | Industry | 48h |  |
| 35 | 1.2.4.4.3 | M&Ps Draft #2 distributed to Industry | milestone | 0d | 2005-11-11 | 2005-11-11 |  |  |  | 107d | 0d | start no earlier than 2005-11-11 | NeuStar |  |  |
| 36 | 1.2.4.4.4 | M&Ps Draft #2 review period by Industry |  | 6d | 2005-11-11 | 2005-11-18 | 35 |  |  | 107d |  | start no earlier than 2003-03-14 | Industry | 48h |  |
| 37 | 1.2.4.4.5 | FINAL Publishing of M&Ps (SLR 26) | milestone | 0d | 2005-11-25 | 2005-11-25 |  |  |  | 103d |  | start no earlier than 2005-11-25 | NeuStar |  |  |
| 38 | 1.2.4.5 | Delta Change Order document completed | milestone | 0d | 2005-06-17 A | 2005-06-17 A |  | 100% |  |  |  | start no earlier than 2005-06-17 | NeuStar |  |  |
| 40 | 1.2.4.6 | Release 3.3 Development Completed | milestone | 0d | 2005-10-28 A | 2005-10-28 A |  | 100% |  |  |  | start no earlier than 2005-10-28 | NeuStar |  |  |
| 42 | 1.2.5 | **Phase 1.3 NeuStar Internal Acceptance of the Enhancement** |  | 76d | 2005-09-19 A | 2006-01-03 |  | 40% | 45.6d | 76d |  |  |  | 600h | 240h |
| 43 | 1.2.5.1 | Start Development of Test Cases | milestone | 0d | 2005-09-19 A | 2005-09-19 A |  | 100% |  |  |  | start no earlier than 2005-09-19 | NeuStar |  |  |
| 44 | 1.2.5.2 | Complete Development of Test Cases |  | 30d | 2005-09-19 A | 2005-10-28 A | 43 | 100% |  |  |  | finish no earlier than 2005-10-28 | NeuStar | 240h | 240h |
| 45 | 1.2.5.3 | Execute Internal Acceptance Testing |  | 45d | 2005-10-31 | 2005-12-30 | 44 |  |  | 77d | 1d | finish no earlier than 2005-12-30 | NeuStar | 360h |  |
| 46 | 1.2.5.4 | NeuStar Software Certification and install on Test bed | milestone | 0d | 2006-01-03 | 2006-01-03 | 45 |  |  | 76d |  | start no earlier than 2006-01-03 | NeuStar |  |  |
| 48 | 1.2.6 | **Phase 1.4 Interoperability Testing** |  | 146d | 2005-04-08 A | 2005-10-28 A |  | 100% |  |  |  |  |  | 2144h | 2144h |
| 49 | 1.2.6.1 | **Interoperability and Test Cases Completion** |  | 85d | 2005-04-08 A | 2005-08-05 A |  | 100% |  |  |  |  |  | 424h | 424h |
| 50 | 1.2.6.1.1 | ITP Test Case List Draft #1 distributed to Industry | milestone | 0d | 2005-04-08 A | 2005-04-08 A |  | 100% |  |  |  | start no earlier than 2005-04-08 | NeuStar |  |  |
| 51 | 1.2.6.1.2 | ITP Test Case List Draft #1 review period by Industry |  | 20d | 2005-04-08 A | 2005-05-05 A | 50 | 100% |  |  |  | start no earlier than 2002-08-09 | Industry | 160h | 160h |
| 52 | 1.2.6.1.3 | ITP Test Case List Draft #2 distributed to Industry | milestone | 0d | 2005-05-13 A | 2005-05-13 A |  | 100% |  |  |  | start no earlier than 2005-05-13 | NeuStar |  |  |
| 53 | 1.2.6.1.4 | ITP Test Case List Draft #2 review period by Industry |  | 11d | 2005-05-13 A | 2005-05-27 A | 52 | 100% |  |  |  | start no earlier than 2002-09-20 | Industry | 88h | 88h |
| 54 | 1.2.6.1.5 | ITP Test Cases - Draft #1 - distributed to Industry | milestone | 0d | 2005-06-17 A | 2005-06-17 A |  | 100% |  |  |  | start no earlier than 2005-06-17 | NeuStar |  |  |
| 55 | 1.2.6.1.6 | ITP Test Cases - Draft #1 - review period by Industry |  | 11d | 2005-06-17 A | 2005-07-01 A | 54 | 100% |  |  |  | start no earlier than 2002-10-17 | Industry | 88h | 88h |
| 56 | 1.2.6.1.7 | ITP Test Cases - Draft #2 - distributed to Industry | milestone | 0d | 2005-07-15 A | 2005-07-15 A |  | 100% |  |  |  | start no earlier than 2005-07-15 | NeuStar |  |  |
| 57 | 1.2.6.1.8 | ITP Test Cases - Draft #2 review period by Industry |  | 11d | 2005-07-15 A | 2005-07-29 A | 56 | 100% |  |  |  | start no earlier than 2002-11-13 | Industry | 88h | 88h |
| 58 | 1.2.6.1.9 | FINAL Publishing of ITP Test Case | milestone | 0d | 2005-08-05 A | 2005-08-05 A |  | 100% |  |  |  | start no earlier than 2005-08-05 | NeuStar |  |  |

| ID | WBS | Task | Type | Duration | Start | Finish | Predecessors | Complete | Remaining | Total slack | Constraint | Resources | Work | Actual work |
| --- | --- | --- | --- | --- | --- | --- | --- | --- | --- | --- | --- | --- | --- | --- |
| 60 | 1.2.6.2 | **ITP Simulator Upgrade** |  | 90d | 2005-04-18 A | 2005-08-19 A |  | 100% |  |  |  | NeuStar | 1440h | 1440h |
| 61 | 1.2.6.2.1 | Implementation of changes to GDMO and ASN.1 |  | 90d | 2005-04-18 A | 2005-08-19 A |  | 100% |  |  | start no earlier than 2005-04-18 | NeuStar/Vendor | 720h | 720h |
| 62 | 1.2.6.3 | Interoperability Test Execution with Vendors |  | 35d | 2005-09-12 A | 2005-10-28 A | 2 | 100% |  |  | finish no earlier than 2003-02-21 | NeuStar & vendors | 280h | 280h |
| 63 | 1.2.6.4 | **ITP Testing Communication Plan** |  | 75d | 2005-07-14 A | 2005-10-27 A |  | 100% |  |  |  |  |  |  |
| 64 | 1.2.6.4.1 | Invite Vendors to sign up for ITP testing | milestone | 0d | 2005-07-14 A | 2005-07-14 A |  | 100% |  |  | start no earlier than 2005-07-14 | NeuStar |  |  |
| 65 | 1.2.6.4.2 | Weekly SP/Vendor ITP Conference call | milestone | 0d | 2005-09-15 A | 2005-09-15 A |  | 100% |  |  | start no earlier than 2005-09-15 | NeuStar |  |  |
| 66 | 1.2.6.4.3 | Weekly SP/Vendor ITP Conference Call | milestone | 0d | 2005-09-22 A | 2005-09-22 A |  | 100% |  |  | start no earlier than 2005-09-22 | NeuStar |  |  |
| 67 | 1.2.6.4.4 | Weekly SP/Vendor ITP Conference call | milestone | 0d | 2005-09-29 A | 2005-09-29 A |  | 100% |  |  | start no earlier than 2005-09-29 | NeuStar |  |  |
| 68 | 1.2.6.4.5 | Weekly SP/Vendor ITP Conference call | milestone | 0d | 2005-10-06 A | 2005-10-06 A |  | 100% |  |  | start no earlier than 2005-10-06 | NeuStar |  |  |
| 69 | 1.2.6.4.6 | Weekly SP/Vendor ITP Conference call | milestone | 0d | 2005-10-13 A | 2005-10-13 A |  | 100% |  |  | start no earlier than 2005-10-13 | NeuStar |  |  |
| 70 | 1.2.6.4.7 | Weekly SP/Vendor ITP Conference call | milestone | 0d | 2005-10-20 A | 2005-10-20 A |  | 100% |  |  | start no earlier than 2005-10-20 | NeuStar |  |  |
| 71 | 1.2.6.4.8 | Weekly SP/Vendor ITP Conference Call | milestone | 0d | 2005-10-27 A | 2005-10-27 A |  | 100% |  |  | start no earlier than 2005-10-27 | NeuStar |  |  |
| 73 | 1.3 | **Phase 2.0 Turn Up Testing Of Enhancement** |  | 277d | 2005-03-28 A | 2006-04-10 |  | 43% | 157.63d | 0d |  |  | 1600h | 624h |
| 74 | 1.3.1 | **Turn Up Test Plan and Test Case Completion** |  | 144d | 2005-03-28 A | 2005-10-14 |  | 99% | 0d | 133d |  |  | 624h | 624h |
| 75 | 1.3.1.1 | Turn Up Test Case List Draft #1 distributed to Industry | milestone | 0d | 2005-03-28 A | 2005-03-28 A |  | 100% |  |  | start no earlier than 2005-03-28 | NeuStar |  |  |
| 76 | 1.3.1.2 | Turn Up Test Case List review period by Industry |  | 30d | 2005-03-28 A | 2005-05-06 A | 75 | 100% |  |  | start no earlier than 2002-08-13 | Industry | 240h | 240h |
| 77 | 1.3.1.3 | Turn Up Test Case List Draft #2 distributed to Industry | milestone | 0d | 2005-05-20 A | 2005-05-20 A |  | 100% |  |  | start no earlier than 2005-05-20 | NeuStar |  |  |
| 78 | 1.3.1.4 | Turn Up Test Case List Draft #2 review period by Industry |  | 11d | 2005-05-20 A | 2005-06-03 A | 77 | 100% |  |  | start no earlier than 2002-10-09 | Industry | 88h | 88h |
| 79 | 1.3.1.5 | Turn Up Test Cases - Draft #1 distributed to Industry | milestone | 0d | 2005-07-01 A | 2005-07-01 A |  | 100% |  |  | start no earlier than 2005-07-01 | NeuStar |  |  |
| 80 | 1.3.1.6 | Turn Up Test Cases - Draft #1 review period by Industry |  | 10d | 2005-07-01 A | 2005-07-14 A | 79 | 100% |  |  | finish no earlier than 2002-12-16 | Industry | 80h | 80h |
| 81 | 1.3.1.7 | Turn UP Test Cases - Review During LNPA WG | milestone | 0d | 2005-07-14 A | 2005-07-14 A |  | 100% |  |  | start no earlier than 2005-07-14 | NeuStar/Industry |  |  |
| 82 | 1.3.1.8 | Turn Up Test Cases - Draft #2 distributed to Industry | milestone | 0d | 2005-08-19 A | 2005-08-19 A |  | 100% |  |  | start no earlier than 2005-08-19 | NeuStar |  |  |
| 83 | 1.3.1.9 | Turn Up Test Cases - Draft #2 review period by Industry |  | 16d | 2005-08-19 A | 2005-09-09 A | 82 | 100% |  |  | start no earlier than 2003-01-20 | Industry | 128h | 128h |
| 84 | 1.3.1.10 | FINAL Publishing of Turn Up Test Plan for R3.3 | milestone | 0d | 2005-09-16 A | 2005-09-16 A |  | 100% |  |  | start no earlier than 2005-09-16 | NeuStar |  |  |
| 85 | 1.3.1.11 | SP Certification & Regression Test Plan with mods for R3.3, distributed to Industry | milestone | 0d | 2005-09-23 A | 2005-09-23 A |  | 100% |  |  | start no earlier than 2005-09-23 | NeuStar |  |  |
| 86 | 1.3.1.12 | SP Certification & Regression Test Plan with mods for R3.3, review period by Industry |  | 11d | 2005-09-23 A | 2005-10-07 A | 85 | 100% |  |  | finish no earlier than 2003-03-03 | Industry | 88h | 88h |
| 87 | 1.3.1.13 | FINAL Publishing of Turn Up Test Plan (3.3.0a). Review produced no changes. | milestone | 0d | 2005-10-14 A | 2005-10-14 |  | 75% | 0d | 133d | start no earlier than 2005-10-14 | NeuStar |  |  |

| ID | WBS | Task | Type | Duration | Start | Finish | Predecessors | Complete | Remaining | Total slack | Free slack | Constraint | Resources | Work |
| --- | --- | --- | --- | --- | --- | --- | --- | --- | --- | --- | --- | --- | --- | --- |
| 88 | 1.3.2 | **Turn Up Test Execution** |  | 41d | 2006-01-03 | 2006-02-24 |  |  |  | 35d |  |  |  | 976h |
| 89 | 1.3.2.1 | **Turn Up Testing Communication Plan** |  | 41d | 2006-01-03 | 2006-02-24 |  |  |  | 35d |  |  |  | 328h |
| 90 | 1.3.2.1.1 | Daily TUT Status reports |  | 41d | 2006-01-03 | 2006-02-24 |  |  |  | 35d |  | finish no earlier than 2006-02-24 | NeuStar | 328h |
| 91 | 1.3.2.1.2 | Weekly SP TUT Conference call | milestone | 0d | 2006-01-05 | 2006-01-05 |  |  |  | 74d |  | start no earlier than 2006-01-05 | NeuStar |  |
| 92 | 1.3.2.1.3 | Weekly SP TUT Conference call | milestone | 0d | 2006-01-12 | 2006-01-12 |  |  |  | 69d |  | start no earlier than 2006-01-12 | NeuStar |  |
| 93 | 1.3.2.1.4 | Weekly SP TUT Conference call | milestone | 0d | 2006-01-19 | 2006-01-19 |  |  |  | 64d |  | start no earlier than 2006-01-19 | NeuStar |  |
| 94 | 1.3.2.1.5 | Weekly SP TUT Conference call | milestone | 0d | 2006-01-26 | 2006-01-26 |  |  |  | 59d |  | start no earlier than 2006-01-26 | NeuStar |  |
| 95 | 1.3.2.1.6 | Weekly SP TUT Conference call | milestone | 0d | 2006-02-02 | 2006-02-02 |  |  |  | 54d |  | start no earlier than 2006-02-02 | NeuStar |  |
| 96 | 1.3.2.1.7 | Weekly SP TUT Conference call | milestone | 0d | 2006-02-09 | 2006-02-09 |  |  |  | 49d |  | start no earlier than 2006-02-09 | NeuStar |  |
| 97 | 1.3.2.1.8 | Weekly SP TUT Conference call | milestone | 0d | 2006-02-16 | 2006-02-16 |  |  |  | 43d |  | start no earlier than 2006-02-16 | NeuStar |  |
| 98 | 1.3.2.1.9 | Weekly SP TUT Conference call | milestone | 0d | 2006-02-23 | 2006-02-23 |  |  |  | 37d |  | start no earlier than 2006-02-23 | NeuStar |  |
| 99 | 1.3.2.2 | **SP Release 3.3 Testing** |  | 41d | 2006-01-03 | 2006-02-24 |  |  |  | 35d |  |  | All SPs | 648h |
| 100 | 1.3.2.2.1 | SP Individual Testing Session |  | 29d | 2006-01-03 | 2006-02-10 |  |  |  | 36d | 1d | finish no earlier than 2006-02-10 | NeuStar/All SPs | 232h |
| 101 | 1.3.2.2.2 | SP Group and Performance Testing |  | 9d | 2006-02-13 | 2006-02-22 | 100 |  |  | 35d | 0d | finish no earlier than 2006-02-22 | NeuStar/All SPs | 72h |
| 102 | 1.3.2.2.3 | SP Failover Testing |  | 2d | 2006-02-23 | 2006-02-24 | 101 |  |  | 35d |  | start no earlier than 2003-05-15 | NeuStar/All SPs | 16h |
| 104 | 1.3.3 | **Phase 3.0 Roll Out of Enhancement** |  | 186d | 2005-08-01 A | 2006-04-09 |  |  | 186d | 1d |  |  |  |  |
| 105 | 1.3.3.1 | EMW (Enhanced Maintenance Window) Blanket Request Completion | milestone | 0d | 2005-12-16 | 2005-12-16 |  |  |  | 88d |  | start no earlier than 2005-12-16 | NeuStar |  |
| 106 | 1.3.3.2 | Send notice to LLC/PEs to prepare for installation sequence | milestone | 0d | 2005-08-01 A | 2005-08-01 A |  | 100% |  |  |  | start no earlier than 2005-08-01 | NeuStar |  |
| 107 | 1.3.3.3 | LLC/PEs Identify sequence of region installation | milestone | 0d | 2005-09-23 A | 2005-09-23 A |  | 100% |  |  |  | start no earlier than 2005-09-23 | NAPM LLC |  |
| 109 | 1.3.3.4 | WC Region Deployed | milestone | 0d | 2006-02-26 | 2006-02-26 |  |  |  | 13d | 0d | start no earlier than 2006-02-26 | NeuStar |  |
| 110 | 1.3.3.5 | WC Region Burn-in period |  | 22d | 2006-02-26 | 2006-03-24 | 109 |  |  | 13d |  |  |  |  |
| 111 | 1.3.3.6 | SE and WE Regions Deployed | milestone | 0d | 2006-03-26 | 2006-03-26 |  |  |  | 13d |  | start no earlier than 2006-03-26 | NeuStar |  |
| 112 | 1.3.3.7 | NE and MW Regions Deployed | milestone | 0d | 2006-04-02 | 2006-04-02 |  |  |  | 7d |  | start no earlier than 2006-04-02 | NeuStar |  |
| 113 | 1.3.3.8 | SW and MA Regions and SOW 34 Deployed | milestone | 0d | 2006-04-09 | 2006-04-09 |  |  |  | 1d |  | start no earlier than 2006-04-09 | NeuStar |  |

| ID | WBS | Task | Type | Duration | Start | Finish | Total slack | Constraint | Resources |
| --- | --- | --- | --- | --- | --- | --- | --- | --- | --- |
| 115 | 1.3.4 | **SOW Close out** |  | 0d | 2006-04-10 | 2006-04-10 | 0d |  |  |
| 116 | 1.3.4.1 | Issue letter to PEs Results of Installation | milestone | 0d | 2006-04-10 | 2006-04-10 | 0d | start no earlier than 2006-04-10 | NeuStar |
| 117 | 1.3.4.2 | Post Mortem Conference Call | milestone | 0d | 2006-04-10 | 2006-04-10 | 0d | start no earlier than 2006-04-10 | NeuStar |
